Schedule from MS Project MPX, 2019-10-18 to 2019-12-23.

## Calendars

- Standard: Mon-Sun 08:00 am-12:00 pm, 01:00 pm-05:00 pm.

## Schedule

| ID | WBS | Task | Duration | Start | Finish | Predecessors |
| --- | --- | --- | --- | --- | --- | --- |
| 1 | 1 | CHL1 Tests (Oportunistic RF On) | 3d | 2019-10-18 | 2019-10-20 |  |
| 2 | 2 | Tunnel Open | 4d | 2019-10-18 | 2019-10-21 |  |
| 3 | 3 | HCO | 5d | 2019-10-21 | 2019-10-25 |  |
| 4 | 4 | SL RF On | 37d | 2019-10-19 | 2019-11-24 |  |
| 5 | 5 | **Injector Setup** | 17d | 2019-10-18 | 2019-11-03 |  |
| 6 | 5.1 | Gun Electrode 130 keV tests | 4d | 2019-10-18 | 2019-10-21 |  |
| 7 | 5.2 | **FC1** | 3d | 2019-10-22 | 2019-10-24 | 6 |
| 8 | 5.2.1 | 4 Laser LLRF Phase Recovery | 1d | 2019-10-22 | 2019-10-22 |  |
| 9 | 5.2.2 | Beam Setup (Inj Group) | 2d | 2019-10-22 | 2019-10-23 |  |
| 10 | 5.2.3 | 130 keV Match | 1d | 2019-10-23 | 2019-10-23 |  |
| 11 | 5.2.4 | Cathode Alignment | 1d | 2019-10-24 | 2019-10-24 |  |
| 12 | 5.2.5 | Parity Settings for all 4 Lasers | 1d | 2019-10-24 | 2019-10-24 |  |
| 13 | 5.2.6 | 0L04 FE Test | 1d | 2019-10-24 | 2019-10-24 |  |
| 14 | 5.3 | **FC2** | 2d | 2019-10-25 | 2019-10-26 | 7 |
| 15 | 5.3.1 | Beam Setup (FCup 2) | 1d | 2019-10-25 | 2019-10-25 |  |
| 16 | 5.3.2 | FCup#2 Centering (Current Discrepency Investigation) | 1d | 2019-10-26 | 2019-10-26 |  |
| 17 | 5.3.3 | 6 MeV Region Match | 1d | 2019-10-26 | 2019-10-26 |  |
| 18 | 5.3.4 | PQB Setup Verification | 1d | 2019-10-26 | 2019-10-26 |  |
| 19 | 5.4 | **ILD** | 8d | 2019-10-27 | 2019-11-03 |  |
| 20 | 5.4.1 | Beam Setup (INJ Group) | 2d | 2019-10-27 | 2019-10-28 |  |
| 21 | 5.4.2 | Inj Matching (Chicane) | 1d | 2019-10-29 | 2019-10-29 |  |
| 22 | 5.4.3 | PQB Setup Verification | 1d | 2019-10-29 | 2019-10-29 |  |
| 23 | 5.4.4 | Other ILD Studies | 5d | 2019-10-30 | 2019-11-03 |  |
| 24 | 6 | NL RF On | 37d | 2019-10-19 | 2019-11-24 |  |
| 25 | 7 | SRF Commisioning (NL Only) | 16d | 2019-10-19 | 2019-11-03 |  |
| 26 | 8 | Set Energy (RF Push) | 2d | 2019-11-04 | 2019-11-05 |  |

Notes:
- 8: http://opsweb.acc.jlab.org/CSUEApps/atlis/task/19407
- 10: Yves to write ATLis
- 11: http://opsweb.acc.jlab.org/CSUEApps/atlis/task/18799
- 12: http://opsweb.acc.jlab.org/CSUEApps/atlis/task/19670
- 13: http://devweb.acc.jlab.org/CSUEApps/atlis/task/18979
- 16: http://devweb.acc.jlab.org/CSUEApps/atlis/task/19617
- 17: Yves to write ATLis
- 18: http://opsweb.acc.jlab.org/CSUEApps/atlis/task/18793
- 20: Yves to write ATLis
- 21: Yves to write ATLis
- 22: http://opsweb.acc.jlab.org/CSUEApps/atlis/task/18793

| ID | WBS | Task | Duration | Start | Finish | Predecessors |
| --- | --- | --- | --- | --- | --- | --- |
| 27 | 9 | **5 pass Spin up** | 7d | 2019-11-06 | 2019-11-12 |  |
| 28 | 9.1 | **Cold Startup** | 3d | 2019-11-06 | 2019-11-08 |  |
| 29 | 9.1.1 | Beam to 1R | 1d | 2019-11-06 | 2019-11-06 |  |
| 30 | 9.1.2 | **INJ Setup Tests (QA) - beam to 1R** | 1d | 2019-11-07 | 2019-11-07 |  |
| 31 | 9.1.2.1 | Colinearity Checks | 1d | 2019-11-07 | 2019-11-07 |  |
| 32 | 9.1.2.2 | Bunch Compresssion using 0L04 | 1d | 2019-11-07 | 2019-11-07 |  |
| 33 | 9.1.2.3 | Ray Ttrace to 1R | 1d | 2019-11-07 | 2019-11-07 |  |
| 34 | 9.1.2.4 | Qualify Inj -> NL Match | 1d | 2019-11-07 | 2019-11-07 |  |
| 35 | 9.1.3 | Beam to 2R | 1d | 2019-11-08 | 2019-11-08 |  |
| 36 | 9.2 | **6 - ORFP ARC by ARC** | 4d | 2019-11-09 | 2019-11-12 |  |
| 37 | 9.2.1 | 6 - ARC4 | 1d | 2019-11-09 | 2019-11-09 |  |
| 38 | 9.2.2 | 7 - ARC7 | 1d | 2019-11-10 | 2019-11-10 | 37 |
| 39 | 9.2.3 | 8 - ARC9 | 1d | 2019-11-11 | 2019-11-11 | 38 |
| 40 | 9.2.4 | 9 - 5C | 1d | 2019-11-12 | 2019-11-12 | 39 |
| 41 | 10 | **Beam Tests to Halls - Dates TBD** | 5d | 2019-11-13 | 2019-11-17 |  |
| 42 | 10.1 | RF Stress Test | 2d | 2019-11-13 | 2019-11-14 |  |
| 43 | 10.2 | Spin Dance | 1d | 2019-11-15 | 2019-11-15 | 42 |
| 44 | 10.3 | Energy Adjustment + Spin Dance | 5d | 2019-11-13 | 2019-11-17 |  |
| 45 | 11 | **Ideas for BS - Dates TBD** | 7d | 2019-11-18 | 2019-11-24 |  |
| 46 | 11.1 | Extraction & Match the Halls | 2d | 2019-11-18 | 2019-11-19 |  |
| 47 | 11.2 | Box Supply Cycling RHEL-7 (Cade) | 1d | 2019-11-20 | 2019-11-20 |  |
| 48 | 11.3 | Machine Reproducibility After Wein Flips | 1d | 2019-11-20 | 2019-11-20 |  |
| 49 | 11.4 | SL Cryo/Electric Heat Balancing - Tief | 1d | 2019-11-20 | 2019-11-20 |  |
| 50 | 11.5 | C100-6R calibration | 1d | 2019-11-20 | 2019-11-20 |  |
| 51 | 11.6 | LEM Reproducibility | 1d | 2019-11-24 | 2019-11-24 |  |
| 52 | 11.7 | NL / SL Drift Box Supply Calibration | 1d | 2019-11-23 | 2019-11-23 |  |
| 53 | 11.8 | Optimimizing BLM/RF/IC Faults | 1d | 2019-11-24 | 2019-11-24 |  |
| 54 | 12 | Physics Start | 29d | 2019-11-25 | 2019-12-23 |  |

Notes:
- 28: Atlis Freeman & Aiken
- 29: Thread Beam Hand Phase Tune Energy Phaser
- 30: -Bunch Compression -Colinearity in Arcs -Ray Trace -Check Gang Phase vs. each laser. (checks relative timing of all 4 lasers). -Verify Inj->NL match / Freeman Atlis
- 31: Position and timing colinearity for all 4 lasers. Check degree of colinearity through to 1R. Check 4 lasers vs. NL Gang phase. ATLis task needed?
- 32: Use Arc Bunch length measurment process to give max compression using 0L04 (minimum spot size in Arc 1 High dispersive region) at Max energy. Freeman to develop and ATLis task for this.
- 33: Tief / Yves
- 34: Step 1-4 in ORFP. Uses 1L02, 1L06, 1L10 viewers to qualify match from the Injector. Is there a better way? Try INJ FOpt correctors to FOpt to 1R?
- 35: Thread through SL Hand Phase SL 2E Match SL Phaser
- 41: Spin up 5 pass beam to Hall A. Spend 3 shifts max, optimizing RF and Beam transport with 600 kW in the Machine.
- 47: http://opsweb.acc.jlab.org/CSUEApps/atlis/atlis.php?load=Task&task_id=19184
- 48: Rematching Early INJ Testing
- 50: Jay Atlis
- 51: Yves to Write ATLIs Checking Early NL Bypass
- 52: http://opsweb.acc.jlab.org/CSUEApps/atlis/task/16981 and http://opsweb.acc.jlab.org/CSUEApps/atlis/task/18319
- 53: Perhaps needed to be done during RF stress testing. / May also require re-calibration of BLM? BLMs too sensitive? BLM setup procedure attached to: http://opsweb.acc.jlab.org/CSUEApps/atlis/task/16634
